# Project- Residential & Commercial SKU's (CDNA 192)

Schedule from MS Project, 2015-11-02 to 2016-11-07, A marks actual dates.

## Calendars

- Standard: Mon-Fri 08:00-12:00, 13:00-17:00; Sat-Sun off.

## Schedule

| ID | WBS | Task | Type | Duration | Start | Finish | Predecessors | Complete | Remaining | Total slack | Free slack | Constraint | Work | Actual work |
| --- | --- | --- | --- | --- | --- | --- | --- | --- | --- | --- | --- | --- | --- | --- |
| 1 | 1 | **Residential & Commercial SKU's (CDNA192)** |  | 266d | 2015-11-02 A | 2016-11-07 |  | 6% | 249.2d | 0d |  |  | 776h | 177.33h |
| 2 | 1.1 | **Phase1_Idea & Concept** |  | 13d | 2015-11-02 A | 2015-11-18 A |  | 100% |  |  |  |  | 136h | 136h |
| 3 | 1.1.1 | SOW |  | 1d | 2015-11-02 A | 2015-11-02 A |  | 100% |  |  |  | start no earlier than 2015-11-02 | 8h | 8h |
| 4 | 1.1.2 | Mktg Input |  | 1d | 2015-11-03 A | 2015-11-03 A | 3 | 100% |  |  |  |  | 8h | 8h |
| 5 | 1.1.3 | Technical Benchmarking |  | 3d | 2015-11-04 A | 2015-11-06 A | 4 | 100% |  |  |  |  | 24h | 24h |
| 6 | 1.1.4 | Design Concepts |  | 5d | 2015-11-09 A | 2015-11-13 A | 5 | 100% |  |  |  |  | 40h | 40h |
| 7 | 1.1.5 | Design Feasibility |  | 5d | 2015-11-09 A | 2015-11-13 A | 5 | 100% |  |  |  |  | 16h | 16h |
| 8 | 1.1.6 | BCP |  | 2d | 2015-11-16 A | 2015-11-17 A | 7 | 100% |  |  |  |  | 32h | 32h |
| 9 | 1.1.7 | Stage Gate 1 |  | 1d | 2015-11-18 A | 2015-11-18 A | 8 | 100% |  |  |  |  | 8h | 8h |
| 10 | 1.2 | **Prtotoype** |  | 29d | 2015-11-18 A | 2015-12-29 | 9 | 10% | 26.1d | 224d |  |  | 72h | 13.01h |
| 11 | 1.2.1 | Project Plan |  | 1d | 2015-11-19 A | 2015-11-19 A | 9 | 100% |  |  |  |  | 8h | 8h |
| 12 | 1.2.2 | Design Input |  | 2d | 2015-11-20 A | 2015-11-23 | 11 | 15% | 1.7d | 250d |  |  | 8h | 1.2h |
| 13 | 1.2.3 | QFD | milestone | 0d | 2015-11-18 A | 2015-11-18 A |  | 100% |  |  |  |  |  |  |
| 14 | 1.2.4 | DFMEA | milestone | 0d | 2015-11-18 A | 2015-11-18 A |  | 100% |  |  |  |  |  |  |
| 15 | 1.2.5 | Test Plan | milestone | 0d | 2015-11-18 A | 2015-11-18 A |  | 100% |  |  |  |  |  |  |
| 16 | 1.2.6 | Patent Search | milestone | 0d | 2015-11-18 A | 2015-11-18 A |  | 100% |  |  |  |  |  |  |
| 17 | 1.2.7 | Concept Modelling |  | 15d | 2015-11-19 A | 2015-12-09 |  | 9% | 13.7d | 238d |  |  | 8h | 0.69h |
| 18 | 1.2.8 | Prototype Planning & Cost |  | 5d | 2015-11-19 A | 2015-11-25 |  | 26% | 3.7d | 248d |  |  | 8h | 2.08h |
| 19 | 1.2.9 | Technical Feasibility Study |  | 10d | 2015-11-19 A | 2015-12-02 |  | 13% | 8.7d | 161d | 0d |  | 8h | 1.04h |
| 20 | 1.2.10 | Product Costing |  | 10d | 2015-12-03 | 2015-12-16 | 19 |  |  | 161d | 0d |  | 8h |  |
| 21 | 1.2.11 | Project costing |  | 5d | 2015-12-17 | 2015-12-23 | 20 |  |  | 161d | 0d |  | 8h |  |
| 22 | 1.2.12 | Performance Testing |  | 3d | 2015-12-24 | 2015-12-28 | 21 |  |  | 161d | 0d |  | 8h |  |
| 23 | 1.2.13 | Product evaluation Dashboard | milestone | 0d | 2015-12-28 | 2015-12-28 | 22 |  |  | 161d | 0d |  |  |  |
| 24 | 1.2.14 | Stage Gate 2 |  | 1d | 2015-12-29 | 2015-12-29 | 23 |  |  | 161d | 0d |  | 8h |  |

| ID | WBS | Task | Duration | Start | Finish | Predecessors | Complete | Remaining | Total slack | Work | Actual work |
| --- | --- | --- | --- | --- | --- | --- | --- | --- | --- | --- | --- |
| 25 | 1.3 | **Phase 3_Detailed Design** | 70d | 2015-12-30 A | 2016-04-05 | 24 | 5% | 66.5d | 154d | 160h | 28.32h |
| 26 | 1.3.1 | Product Data sheets | 1d | 2015-12-30 A | 2015-12-30 |  | 33% | 0.67d | 223d | 8h | 2.63h |
| 27 | 1.3.2 | Product Appearance | 1d | 2015-12-30 A | 2015-12-30 |  | 33% | 0.67d | 223d | 8h | 2.63h |
| 28 | 1.3.3 | Product Mounting detail | 1d | 2015-12-30 A | 2015-12-30 |  | 33% | 0.67d | 223d | 8h | 2.63h |
| 29 | 1.3.4 | Product Size standard detail | 1d | 2015-12-30 A | 2015-12-30 |  | 33% | 0.67d | 223d | 8h | 2.63h |
| 30 | 1.3.5 | Modelling | 50d | 2015-12-30 A | 2016-03-08 |  | 1% | 49.67d | 0d | 8h | 0.05h |
| 31 | 1.3.6 | Design Analysis | 7d | 2016-03-09 | 2016-03-17 | 30 |  |  | 167d | 8h |  |
| 32 | 1.3.7 | Fit & Function Drg | 3d | 2015-12-30 A | 2016-01-01 |  | 11% | 2.67d | 221d | 8h | 0.88h |
| 33 | 1.3.8 | Tolerance analysis | 2d | 2015-12-30 A | 2015-12-31 |  | 16% | 1.67d | 222d | 8h | 1.32h |
| 34 | 1.3.9 | Structure analysis | 1d | 2015-12-30 A | 2015-12-30 |  | 33% | 0.67d | 223d | 8h | 2.63h |
| 35 | 1.3.10 | Mould flow analysis | 3d | 2015-12-30 A | 2016-01-01 |  | 11% | 2.67d | 221d | 8h | 0.88h |
| 36 | 1.3.11 | Material selection sheet | 2d | 2015-12-30 A | 2015-12-31 |  | 16% | 1.67d | 222d | 8h | 1.32h |
| 37 | 1.3.12 | Engg. Prototype Planning & Cost | 1d | 2015-12-30 A | 2015-12-30 |  | 33% | 0.67d | 223d | 8h | 2.63h |
| 38 | 1.3.13 | Testing Results | 3d | 2015-12-30 A | 2016-01-01 |  | 11% | 2.67d | 221d | 8h | 0.88h |
| 39 | 1.3.14 | Final Drawings | 20d | 2016-03-09 | 2016-04-05 | 30 |  |  | 154d | 8h |  |
| 40 | 1.3.15 | Drafted models | 5d | 2015-12-30 A | 2016-01-05 |  | 7% | 4.67d | 219d | 8h | 0.53h |
| 41 | 1.3.16 | Engg. BOM | 5d | 2015-12-30 A | 2016-01-05 |  | 7% | 4.67d | 219d | 8h | 0.53h |
| 42 | 1.3.17 | Product Costing | 3d | 2015-12-30 A | 2016-01-01 |  | 11% | 2.67d | 221d | 8h | 0.88h |
| 43 | 1.3.18 | Project Dashboard | 1d | 2015-12-30 A | 2015-12-30 |  | 33% | 0.67d | 223d | 8h | 2.63h |
| 44 | 1.3.19 | Product Evaluation Dashboard | 1d | 2015-12-30 A | 2015-12-30 |  | 33% | 0.67d | 223d | 8h | 2.63h |
| 45 | 1.3.20 | Stage Gate 3 | 1d | 2016-03-09 | 2016-03-09 | 30 |  |  | 0d | 8h |  |
| 46 | 1.4 | **Phase 4_Tooling & Part Approval** | 151d | 2016-03-10 | 2016-10-06 | 45 |  |  | 0d | 136h |  |
| 47 | 1.4.1 | Tool Specifications | 3d | 2016-03-10 | 2016-03-14 | 45 |  |  | 0d | 8h |  |
| 48 | 1.4.2 | Tool Quotations | 3d | 2016-03-15 | 2016-03-17 | 47 |  |  | 0d | 8h |  |
| 49 | 1.4.3 | Tool Purchase Orders | 3d | 2016-03-18 | 2016-03-22 | 48 |  |  | 0d | 8h |  |
| 50 | 1.4.4 | Tool Design Approval | 7d | 2016-03-23 | 2016-03-31 | 49 |  |  | 0d | 8h |  |

| ID | WBS | Task | Duration | Start | Finish | Predecessors | Total slack | Free slack | Work |
| --- | --- | --- | --- | --- | --- | --- | --- | --- | --- |
| 51 | 1.4.5 | **Production Process flow** | 10d | 2016-04-01 | 2016-04-14 |  | 0d |  | 48h |
| 52 | 1.4.5.1 | Production Process Lay-out | 1d | 2016-04-01 | 2016-04-01 | 50 | 0d |  | 8h |
| 53 | 1.4.5.2 | Process(Finalise Jig / Fixtures) | 2d | 2016-04-04 | 2016-04-05 | 52 | 0d |  | 8h |
| 54 | 1.4.5.3 | Equipment Specifications | 1d | 2016-04-06 | 2016-04-06 | 53 | 0d |  | 8h |
| 55 | 1.4.5.4 | Equipment Quotations | 2d | 2016-04-07 | 2016-04-08 | 54 | 0d |  | 8h |
| 56 | 1.4.5.5 | Equipment Orders | 3d | 2016-04-11 | 2016-04-13 | 55 | 0d |  | 8h |
| 57 | 1.4.5.6 | Equipment Design Approval | 1d | 2016-04-14 | 2016-04-14 | 56 | 0d |  | 8h |
| 58 | 1.4.6 | Tool Manufacturing | 90d | 2016-04-15 | 2016-08-18 | 57 | 0d |  | 8h |
| 59 | 1.4.7 | Part Approvals | 35d | 2016-08-19 | 2016-10-06 | 58 | 0d |  | 8h |
| 60 | 1.4.8 | Product Approval(Product Approval with test reports) | 30d | 2016-04-15 | 2016-05-26 | 57 | 95d |  | 8h |
| 61 | 1.4.9 | Equipment Approvals | 1d | 2016-04-15 | 2016-04-15 | 57 | 90d | 0d | 8h |
| 62 | 1.4.10 | Off Tool Parts(Finalise Costs and Order Off Tool Parts) | 2d | 2016-04-18 | 2016-04-19 | 61 | 90d | 0d | 8h |
| 63 | 1.4.11 | Check List for DATA | 1d | 2016-04-20 | 2016-04-20 | 62 | 90d | 0d | 8h |
| 64 | 1.4.12 | Stage Gate 4 | 1d | 2016-04-21 | 2016-04-21 | 63 | 90d | 0d | 8h |
| 65 | 1.5 | **Phase 5_Pre Production & Correction** | 30d | 2016-04-22 | 2016-06-02 |  | 90d |  | 104h |
| 66 | 1.5.1 | **Work Instructions** | 1d | 2016-04-22 | 2016-04-22 |  | 90d |  | 8h |
| 67 | 1.5.1.1 | Process Sheet / Work Instructions | 1d | 2016-04-22 | 2016-04-22 | 64 | 90d | 0d | 8h |
| 68 | 1.5.2 | Control Plan | 3d | 2016-04-25 | 2016-04-27 | 67 | 90d | 0d | 8h |
| 69 | 1.5.3 | PFMEA | 3d | 2016-04-28 | 2016-05-02 | 68 | 90d | 0d | 8h |
| 70 | 1.5.4 | Inspection & Tests Plan | 3d | 2016-05-03 | 2016-05-05 | 69 | 90d | 0d | 8h |
| 71 | 1.5.5 | Product Printing | 15d | 2016-05-06 | 2016-05-26 | 70 | 117d |  | 8h |
| 72 | 1.5.6 | Product Packing | 20d | 2016-05-06 | 2016-06-02 | 70 | 112d |  | 8h |
| 73 | 1.5.7 | Product Installation sheet & User guide | 1d | 2016-05-06 | 2016-05-06 | 70 | 131d |  | 8h |
| 74 | 1.5.8 | Catalogue | 15d | 2016-05-06 | 2016-05-26 | 70 | 90d | 0d | 8h |

| ID | WBS | Task | Duration | Start | Finish | Predecessors | Total slack | Free slack | Work |
| --- | --- | --- | --- | --- | --- | --- | --- | --- | --- |
| 75 | 1.5.9 | **Product Profile** | 2d | 2016-05-27 | 2016-05-30 |  | 90d |  | 16h |
| 76 | 1.5.9.1 | Create Product Profile and PPT | 1d | 2016-05-27 | 2016-05-27 | 74 | 90d | 0d | 8h |
| 77 | 1.5.9.2 | Install Manufacturing Equipment | 1d | 2016-05-30 | 2016-05-30 | 76 | 90d | 0d | 8h |
| 78 | 1.5.10 | Manufacturing Training & Skill Matrix | 1d | 2016-05-31 | 2016-05-31 | 77 | 90d | 0d | 8h |
| 79 | 1.5.11 | Design Output | 1d | 2016-06-01 | 2016-06-01 | 78 | 90d | 0d | 8h |
| 80 | 1.5.12 | Stage Gate 5 | 1d | 2016-06-02 | 2016-06-02 | 79 | 90d |  | 8h |
| 81 | 1.6 | **Phase 6_Production** | 20d | 2016-10-07 | 2016-11-03 | 46 | 0d |  | 152h |
| 82 | 1.6.1 | **Output File Documentation** | 13d | 2016-10-07 | 2016-10-25 |  | 0d |  | 104h |
| 83 | 1.6.1.1 | PRODUCT SPECIFICATION | 1d | 2016-10-07 | 2016-10-07 | 80 | 0d |  | 8h |
| 84 | 1.6.1.2 | IN HOUSE VALIDATION REPORT | 1d | 2016-10-10 | 2016-10-10 | 83 | 0d |  | 8h |
| 85 | 1.6.1.3 | ENGG. BOM | 1d | 2016-10-11 | 2016-10-11 | 84 | 0d |  | 8h |
| 86 | 1.6.1.4 | CONTROLLED DRAWINGS | 1d | 2016-10-12 | 2016-10-12 | 85 | 0d |  | 8h |
| 87 | 1.6.1.5 | PART APPROVAL REPORTS | 1d | 2016-10-13 | 2016-10-13 | 86 | 0d |  | 8h |
| 88 | 1.6.1.6 | PURCHASING SPECIFICATIONS | 1d | 2016-10-14 | 2016-10-14 | 87 | 0d |  | 8h |
| 89 | 1.6.1.7 | PURCHASING SPECIFICATIONS (COMPONENTS) | 1d | 2016-10-17 | 2016-10-17 | 88 | 0d |  | 8h |
| 90 | 1.6.1.8 | PRINTING & PACKING | 1d | 2016-10-18 | 2016-10-18 | 89 | 0d |  | 8h |
| 91 | 1.6.1.9 | ASSEMBLY PROCESS FLOW CHARTS/ WORK INSTRUCTIONS | 1d | 2016-10-19 | 2016-10-19 | 90 | 0d |  | 8h |
| 92 | 1.6.1.10 | PROCESS CONTROL SHEETS (Check sheet) | 1d | 2016-10-20 | 2016-10-20 | 91 | 0d |  | 8h |
| 93 | 1.6.1.11 | QA PLAN | 1d | 2016-10-21 | 2016-10-21 | 92 | 0d |  | 8h |
| 94 | 1.6.1.12 | MASTER LIST OF JIGS & FIXTURES/GAUGES | 1d | 2016-10-24 | 2016-10-24 | 93 | 0d |  | 8h |
| 95 | 1.6.1.13 | FINAL ACCEPTANCE REPORT | 1d | 2016-10-25 | 2016-10-25 | 94 | 0d |  | 8h |
| 96 | 1.6.2 | SAP Codes | 1d | 2016-10-26 | 2016-10-26 | 95 | 0d |  | 8h |
| 97 | 1.6.3 | Production BOM in SAP | 1d | 2016-10-27 | 2016-10-27 | 96 | 0d |  | 8h |
| 98 | 1.6.4 | Part List for 1st Sales Order | 1d | 2016-10-28 | 2016-10-28 | 97 | 0d |  | 8h |
| 99 | 1.6.5 | Report First Pass Yield | 2d | 2016-10-31 | 2016-11-01 | 98 | 0d |  | 8h |
| 100 | 1.6.6 | List of Technical Remarks | 1d | 2016-11-02 | 2016-11-02 | 99 | 0d |  | 8h |
| 101 | 1.6.7 | Stage Gate 6 | 1d | 2016-11-03 | 2016-11-03 | 100 | 0d |  | 8h |

| ID | WBS | Task | Duration | Start | Finish | Predecessors | Total slack | Work |
| --- | --- | --- | --- | --- | --- | --- | --- | --- |
| 102 | 1.7 | **Phase 7_Evaluation** | 2d | 2016-11-04 | 2016-11-07 |  | 0d | 16h |
| 103 | 1.7.1 | List of Technical Remarks | 1d | 2016-11-04 | 2016-11-04 | 101 | 0d | 8h |
| 104 | 1.7.2 | Product Handover to Plant | 1d | 2016-11-07 | 2016-11-07 | 103 | 0d | 8h |
